# Tki_aikataulu

Schedule from MS Project, 2013-12-20 to 2014-04-24, A marks actual dates.
Metropolia

## Calendars

- Standard: Mon-Fri 08:00-12:00, 13:00-17:00; Sat-Sun off.

## Resources

| Resource |
| --- |
| ABB |
| ABB, projektitiimi |
| Projektitiimi |
| Koulu |

## Schedule

| ID | WBS | Task | Type | Duration | Start | Finish | Predecessors | Complete | Remaining | Total slack | Resources | Work | Actual work |
| --- | --- | --- | --- | --- | --- | --- | --- | --- | --- | --- | --- | --- | --- |
| 1 | 1 | **Esikäsittelytilan toteutussuunnittelu** |  | 90d? | 2013-12-20 A | 2014-04-24 |  | 28% | 65.22d? | 0d |  | 680h | 208h |
| 2 | 1.1 | **Aloitus** |  | 38d | 2013-12-20 A | 2014-02-11 |  | 95% | 1.9d | 0d |  | 216h | 208h |
| 3 | 1.1.1 | Aloitustapaaminen | manual | 1d | 2013-12-20 A | 2013-12-23 A |  | 100% |  |  | ABB; Projektitiimi | 16h | 16h |
| 4 | 1.1.2 | Aloituskokous | manual | 1d | 2014-01-16 A | 2014-01-16 A | 3 | 100% |  |  | Projektitiimi | 8h | 8h |
| 5 | 1.1.3 | Projektisuunnitelman luonti | manual | 11d | 2014-01-17 A | 2014-01-31 A | 4 | 100% |  |  | Projektitiimi | 88h | 88h |
| 6 | 1.1.4 | Projektin aloitus, esikäsittelytilan mitoitus | manual | 6d | 2014-02-03 A | 2014-02-10 A | 5 | 100% |  |  | ABB; Projektitiimi | 96h | 96h |
| 7 | 1.1.5 | Suunnitelman palautus | manual | 1d | 2014-02-11 | 2014-02-11 | 6 |  |  |  | Projektitiimi | 8h |  |
| 8 | 1.2 | **Suunnittelu/Toteutus** |  | 32d | 2014-02-12 | 2014-03-27 |  |  |  | 0d |  | 256h |  |
| 9 | 1.2.1 | Uuden layoutin suunnittelu | manual | 11d | 2014-02-12 | 2014-02-26 | 7 |  |  |  | Projektitiimi | 88h |  |
| 10 | 1.2.2 | Mallinnus, pohjapiirros | manual | 10d | 2014-02-27 | 2014-03-12 | 9 |  |  |  | Projektitiimi | 80h |  |
| 11 | 1.2.3 | Mallinnus, uusi layout | manual | 11d | 2014-03-13 | 2014-03-27 | 10 |  |  |  | Projektitiimi | 88h |  |
| 12 | 1.3 | **Kokoukset** |  | 26d | 2014-02-06 | 2014-03-13 |  |  |  | 0d |  | 48h |  |
| 13 | 1.3.1 | Välipalaveri, Suunnitelman esittely | manual | 1d | 2014-02-06 | 2014-02-06 |  |  |  |  | Projektitiimi; Koulu | 16h |  |
| 14 | 1.3.2 | Välipalaveri, suunnitelman esittely | milestone, manual | 0d | 2014-02-06 | 2014-02-06 | 13 |  |  |  | ABB, projektitiimi |  |  |
| 15 | 1.3.3 | Projektikokous, viestintä | manual | 1d | 2014-02-27 | 2014-02-27 | 14 |  |  |  | Koulu; Projektitiimi | 16h |  |
| 16 | 1.3.4 | Tilannekatsaus | manual | 1d | 2014-03-13 | 2014-03-13 | 15 |  |  |  | Projektitiimi; Koulu | 16h |  |
| 17 | 1.4 | **Lopetus** |  | 27d? | 2014-03-19 | 2014-04-24 |  |  |  | 0d |  | 160h |  |
| 18 | 1.4.1 | Suunnitelman esittely | manual | 1d? | 2014-03-19 | 2014-03-19 | 16 |  |  |  | ABB; Projektitiimi; Koulu | 24h |  |
| 19 | 1.4.2 | Loppuraportin aloitus | manual | 11d | 2014-03-20 | 2014-04-03 | 18 |  |  |  | Projektitiimi | 88h |  |
| 20 | 1.4.3 | Loppuraporttiaihion palautus | manual | 1d | 2014-04-10 | 2014-04-10 | 19 |  |  |  | Koulu; Projektitiimi; ABB | 24h |  |
| 21 | 1.4.4 | Loppuraportin luovutus - seminaari | manual | 1d | 2014-04-24 | 2014-04-24 | 20 |  |  |  | ABB; Koulu; Projektitiimi | 24h |  |
